# 5-0SpringDeadlines(OVERALL-4-25)

Schedule from MS Project, 2007-01-16 to 2007-05-01.
University of Notre Dame

## Calendars

- Standard: Mon-Fri 08:00-12:00, 13:00-17:00; Sat-Sun off. Exceptions (off unless hours are given): 2007-04-22 08:00-12:00, 13:00-17:00.

## Resources

| Resource |
| --- |
| All of Group |
| Pete and Jason |
| Mike and Marty |
| Pete |
| Jason |
| Marty |
| Mike and Jason |
| Mike |

## Schedule

| ID | Task | Type | Duration | Start | Finish | Predecessors | Total slack | Free slack | Constraint | Resources | Work |
| --- | --- | --- | --- | --- | --- | --- | --- | --- | --- | --- | --- |
| 1 | SBPD Meeting |  | 4d? | 2007-01-16 | 2007-01-19 |  | 73d |  | finish no earlier than 2007-01-19 | All of Group | 32h |
| 2 | Sample Sensors Testing |  | 5d? | 2007-01-16 | 2007-01-22 |  | 45d | 0d | finish no earlier than 2007-01-22 | Pete and Jason | 40h |
| 3 | Sample Switching Testing |  | 5d? | 2007-01-16 | 2007-01-22 |  | 45d | 0d | finish no earlier than 2007-01-22 | Pete and Jason | 40h |
| 4 | Decide/Order Hardware Components |  | 3d? | 2007-01-23 | 2007-01-25 | 2, 3 | 45d | 0d | finish no earlier than 2007-01-25 | All of Group | 24h |
| 5 | Develop Sensing Prototype |  | 24d? | 2007-01-26 | 2007-02-28 | 4 | 45d |  | start no earlier than 2007-01-26 | Pete and Jason | 192h |
| 6 | Develop Switching Prototype |  | 24d? | 2007-01-26 | 2007-02-28 | 4 | 45d |  | start no earlier than 2007-01-26 | Pete and Jason | 192h |
| 7 | Trace Car Schematic |  | 24d? | 2007-01-26 | 2007-02-28 | 4 | 45d |  | start no earlier than 2007-01-26 | Pete and Jason | 192h |
| 8 | Housing Model Designed |  | 7d? | 2007-02-20 | 2007-02-28 |  | 45d |  | start no earlier than 2007-02-20 | Pete and Jason | 56h |
| 9 | Flow Chart / System Outline |  | 7d | 2007-01-16 | 2007-01-24 |  | 50d | 0d | finish no earlier than 2007-01-24 | Mike and Marty | 56h |
| 10 | Port Configuration |  | 10d | 2007-01-25 | 2007-02-07 | 9 | 50d | 0d |  | Mike and Marty | 80h |
| 11 | Writing Microprocessor Routines |  | 10d | 2007-02-08 | 2007-02-21 | 10 | 50d |  | finish no earlier than 2007-02-21 | Mike and Marty | 80h |
| 12 | Swap battery | milestone | 0d? | 2007-03-25 | 2007-03-25 |  | 28d |  | start no earlier than 2007-03-25 | Mike and Jason |  |
| 13 | test max currents in car |  | 1d? | 2007-04-22 | 2007-04-22 |  | 7d |  | start no earlier than 2007-04-22 | Mike and Jason | 8h |
| 14 | note wire sizes in car | milestone | 0d? | 2007-03-25 | 2007-03-25 |  | 28d |  | start no earlier than 2007-03-25 | Jason |  |
| 15 | eagle schematic |  | 31d? | 2007-03-09 | 2007-04-20 |  | 8d |  | start no earlier than 2007-03-09 | Pete and Jason | 248h |
| 16 | breadboard circuit model |  | 20d? | 2007-03-05 | 2007-03-30 |  | 23d |  | start no earlier than 2007-03-05 | Pete and Jason | 160h |
| 17 | Final Parts Order |  | 4d? | 2007-04-17 | 2007-04-20 |  | 8d |  | start no earlier than 2007-04-17 | All of Group | 32h |
| 18 | Justify / Fix Subsystem Approaches |  | 6d? | 2007-04-03 | 2007-04-10 |  | 16d |  | start no earlier than 2007-04-03 | Pete; Jason; Marty | 144h |
| 19 | Development of Installation / Test Plan |  | 7d? | 2007-04-20 | 2007-04-27 |  | 2d |  | finish no earlier than 2007-04-27 | All of Group | 56h |
| 20 | Final Report and Appendices |  | 7d? | 2007-04-20 | 2007-04-27 |  | 2d |  | finish no earlier than 2007-04-27 | All of Group | 56h |
| 21 | LCD Interface Approach / Functuality |  | 27d? | 2007-03-23 | 2007-04-27 |  | 2d |  | finish no earlier than 2007-04-27 | Marty | 216h |
| 22 | Microcontroller Code |  | 13d? | 2007-04-16 | 2007-05-01 |  | 0d |  | finish no earlier than 2007-05-01 | Mike | 104h |

Notes:
- 10: Write a routine that properly sets necessary in-out ports, A/D conversion ports, settings for timer chip and external EEPROM, etc.
- 11: Routines: / ·Battery Check / ·Alternator Detector / ·Battery Charging Detector / ·Switching for Good, Critical, etc. modes / ·"Sleep" Mode Routine / ·Code for system messages written to memory (requires integration with digital time-chip specs, which is why it's being pushed over here instead of with the port configuration stuff). / All of this will require some deal of integration with the hardware team, to facilitate a smooth integration of subsystems after Feb. 28
